# KFPAGantt

Schedule from MS Project, 2007-06-04 to 2010-12-16, A marks actual dates.
NRAO

## Calendars

- Standard: Mon-Fri 08:00-12:00, 13:00-17:00; Sat-Sun off.

## Resources

| Resource |
| --- |
| Sri |
| Roger Dickenson |
| Dwayne Barker |
| Bob Simon |
| Steve White |
| Gary Anderson |
| Eric Bryerton |
| Matt Morgan |
| Harry Sipe |
| Galen Watts |
| Ken Ward |
| Roger Norrod |
| s |
| Petincin |
| R |
| Peticin |
| Glen Langston |
| Petencin |
| Patrick Brandt |
| Chuck Niday |
| Amy Shelton |
| Bob Garwood |
| Gerry Petencin |
| Mark Whitehead |
| Peeincin |
| Nathan Sharp |

## Schedule

| ID | WBS | Task | Duration | Start | Finish | Predecessors | Complete | Remaining | Total slack | Constraint | Resources | Work | Actual work |
| --- | --- | --- | --- | --- | --- | --- | --- | --- | --- | --- | --- | --- | --- |
| 1 | 1 | **System Design** | 154d | 2007-07-31 A | 2008-02-29 A |  | 100% |  |  |  |  |  |  |
| 2 | 1.1 | Write Final Spec | 5mo | 2007-07-31 A | 2007-12-31 A |  | 100% |  |  | finish no earlier than 2007-12-31 |  |  |  |
| 3 | 1.2 | Define Interfaces | 5mo | 2007-10-01 A | 2008-02-29 A |  | 100% |  |  | start no earlier than 2007-10-01 |  |  |  |
| 4 | 1.3 | LO Distribution (LOD) | 5mo | 2007-10-01 A | 2008-02-29 A |  | 100% |  |  | start no earlier than 2007-10-01 |  |  |  |
| 5 | 1.4 | Itegrated Downconverter (IDM) | 5mo | 2007-10-01 A | 2008-02-29 A |  | 100% |  |  | start no earlier than 2007-10-01 |  |  |  |
| 6 | 1.5 | Noise Cal Module (NCM) | 5mo | 2007-10-01 A | 2008-02-29 A |  | 100% |  |  | start no earlier than 2007-10-01 |  |  |  |
| 7 | 1.6 | Design Feedhorn | 2w | 2007-10-15 A | 2007-10-26 A |  | 100% |  |  | start no earlier than 2007-10-15 |  |  |  |
| 8 | 1.7 | Draft Feed Horn | 2w | 2007-10-29 A | 2007-11-09 A | 7 | 100% |  |  |  |  |  |  |
| 9 | 1.8 | Feed Contruct and Measure | 9w | 2007-11-12 A | 2008-01-11 A | 8 | 100% |  |  |  |  |  |  |
| 10 | 2 | Conceptual Design Review | 2d | 2008-02-27 A | 2008-02-28 A |  | 100% |  |  | start no earlier than 2008-02-27 |  |  |  |
| 11 | 3 | **Single Pixel Fabrication & Meas** | 197d | 2007-12-03 A | 2008-09-02 |  | 98% | 4.42d | 597d |  |  | 5512h | 5352h |
| 12 | 3.1 | **Cryostat Fabrication Single Pixel** | 25d | 2008-04-28 A | 2008-05-30 |  | 80% | 5d | 664d |  | Roger Dickenson | 360h | 280h |
| 13 | 3.1.1 | Thermal Transition | 3w | 2008-04-28 A | 2008-05-16 A |  | 100% |  |  | start no earlier than 2008-04-28 | Roger Dickenson | 120h | 120h |
| 14 | 3.1.2 | Dewar Top Plate | 1w | 2008-05-19 A | 2008-05-23 A | 13 | 100% |  |  |  | Roger Dickenson | 40h | 40h |
| 15 | 3.1.3 | Bottom Plate | 1w | 2008-05-26 | 2008-05-30 | 14 |  |  | 558d |  | Roger Dickenson | 40h |  |
| 16 | 3.2 | LOD Module | 8w | 2008-07-09 A | 2008-09-02 A |  | 100% |  |  | finish no earlier than 2008-09-02 | Gary Anderson | 320h | 320h |
| 17 | 3.3 | IDM Module | 12w | 2008-05-20 A | 2008-08-11 A |  | 100% |  |  | finish no earlier than 2008-08-11 | Eric Bryerton | 480h | 480h |
| 18 | 3.4 | NCM Module | 17w | 2008-04-08 A | 2008-08-04 A |  | 100% |  |  | finish no earlier than 2008-08-04 | Matt Morgan | 680h | 680h |
| 19 | 3.5 | M&C Hardware | 17.8w | 2008-04-16 A | 2008-08-18 A |  | 100% |  |  | finish no earlier than 2008-08-18 | Galen Watts | 712h | 712h |
| 20 | 3.6 | Electroform Phase Shifter Mandrels | 15w | 2007-12-04 A | 2008-03-17 A |  | 100% |  |  |  | Roger Dickenson | 600h | 600h |
| 21 | 3.7 | Test Phase Shifter | 7d | 2008-03-18 A | 2008-03-26 A | 20 | 100% |  |  |  | Roger Dickenson | 56h | 56h |
| 22 | 3.8 | Fabricate OMT (4) | 2mo | 2008-01-01 A | 2008-02-29 A |  | 100% |  |  | start no earlier than 2008-01-01 | Dwayne Barker | 352h | 352h |
| 23 | 3.9 | Test OMT | 4d | 2008-03-03 A | 2008-03-06 A | 22 | 100% |  |  |  | Steve White | 32h | 32h |
| 24 | 3.10 | Fabricate Phase Shifter (5) | 2w | 2008-03-18 A | 2008-03-31 A | 20 | 100% |  |  | start no earlier than 2008-03-10 | Roger Dickenson | 80h | 80h |
| 25 | 3.11 | Electroform and Finish 90 PS | 2mo | 2008-04-01 A | 2008-05-30 A | 24 | 100% |  |  |  | Roger Dickenson | 352h | 352h |
| 26 | 3.12 | Fabricate 45 Degree Twist (9) | 4mo | 2007-12-03 A | 2008-04-02 A |  | 100% |  |  | start no earlier than 2007-12-03 | Roger Dickenson | 704h | 704h |
| 27 | 3.13 | Fabricate Circular to Square (8) | 3mo | 2008-01-01 A | 2008-04-01 A |  | 100% |  |  | start no earlier than 2008-01-01 | Roger Dickenson | 528h | 528h |
| 28 | 3.14 | Test PS,45,Cir to Square | 2w | 2008-06-02 | 2008-06-13 | 25, 26, 27 |  |  | 548d |  | Sri | 80h |  |
| 29 | 3.15 | Output Waveguide Construction | 1mo | 2008-03-03 A | 2008-04-01 A |  | 100% |  |  | start no earlier than 2008-03-03 | Ken Ward | 176h | 176h |

| ID | WBS | Task | Duration | Start | Finish | Predecessors | Complete | Remaining | Total slack | Free slack | Constraint | Resources | Work | Actual work |
| --- | --- | --- | --- | --- | --- | --- | --- | --- | --- | --- | --- | --- | --- | --- |
| 30 | 4 | **Output Waveguide Thermal Gap** | 49d | 2008-03-25 A | 2008-05-30 A |  | 100% |  |  |  |  |  | 280h | 280h |
| 31 | 4.1 | Design and modeling | 4w | 2008-03-25 A | 2008-04-21 A |  | 100% |  |  |  | start no earlier than 2008-03-25 | Roger Norrod | 160h | 160h |
| 32 | 4.2 | Fabrication | 2w | 2008-05-12 A | 2008-05-23 A | 31 | 100% |  |  |  | start no earlier than 2008-05-12 | Harry Sipe | 80h | 80h |
| 33 | 4.3 | Testing | 1w | 2008-05-26 A | 2008-05-30 A | 32 | 100% |  |  |  |  | Roger Norrod | 40h | 40h |
| 34 | 5 | **Monitor and Control Prototype** | 174d | 2008-03-03 A | 2008-10-30 A |  | 100% |  |  |  |  |  | 1056h | 1056h |
| 35 | 5.1 | M&C Hardware Module | 5mo | 2008-03-03 A | 2008-08-01 A |  | 100% |  |  |  |  | Galen Watts | 880h | 880h |
| 36 | 5.2 | M&C Software | 1mo | 2008-10-01 A | 2008-10-30 A | 35 | 100% |  |  |  | finish no earlier than 2008-09-08 | Patrick Brandt | 176h | 176h |
| 37 | 6 | Contruct single pixel | 3w | 2008-08-28 A | 2008-09-17 A |  | 100% |  |  |  |  | Bob Simon | 120h | 120h |
| 38 | 7 | Testing | 3w | 2008-08-28 A | 2008-09-17 A |  | 100% |  |  |  | start no earlier than 2008-08-28 | Bob Simon | 120h | 120h |
| 39 | 8 | Single Pixel Commissioning | 3.5mo | 2008-09-03 A | 2008-12-18 A | 35, 11 | 100% |  |  |  |  | Bob Simon | 616h | 616h |
| 40 | 9 | Critical Design Review | 2d | 2009-01-30 A | 2009-02-02 A |  | 100% |  |  |  | start no earlier than 2009-01-30 | Steve White | 16h | 16h |
| 41 | 10 | **Monitor and Control Finalized** | 144d | 2009-01-05 A | 2009-07-23 |  | 98% | 2.24d | 365d |  |  |  | 1600h | 1600h |
| 42 | 10.1 | M&C Hardware Design Change | 6w | 2009-01-05 A | 2009-02-13 A |  | 100% |  |  |  | finish no earlier than 2008-09-08 | Galen Watts | 240h | 240h |
| 43 | 10.2 | M&C Hardware uC | 1mo | 2009-02-02 A | 2009-03-03 A |  | 100% |  |  |  | start no earlier than 2009-02-02 | Chuck Niday | 176h | 176h |
| 44 | 10.3 | M&C Enable Boards | 2mo | 2009-03-02 A | 2009-04-30 A |  | 100% |  |  |  |  | Chuck Niday | 352h | 352h |
| 45 | 10.4 | Construct Enable Boards | 12w | 2009-05-01 A | 2009-07-23 A | 44 | 100% |  |  |  |  | Nathan Sharp | 480h | 480h |
| 46 | 10.5 | M&C Back Plane Board | 2mo | 2009-02-09 A | 2009-04-09 A |  | 100% |  |  |  | start no earlier than 2009-02-09 | Chuck Niday | 352h | 352h |
| 47 | 10.6 | Construct Back Plane Board | 2w | 2009-06-08 A | 2009-06-19 A |  | 100% |  |  |  | start no earlier than 2009-06-08 |  |  |  |
| 48 | 10.7 | RFI Boxes | 5d | 2009-06-15 A | 2009-06-19 |  | 33% | 3.35d | 389d |  | start no earlier than 2009-06-15 |  |  |  |
| 49 | 11 | **Manager** | 156d | 2009-03-02 A | 2009-10-05 |  | 29% | 111.43d | 313d |  |  |  | 560h | 240h |
| 50 | 11.1 | Generate MR's | 30d | 2009-03-02 A | 2009-04-10 A |  | 100% |  |  |  | start no earlier than 2009-03-02 | Mark Whitehead | 240h | 240h |
| 51 | 11.2 | Prototype with uC | 30d | 2009-03-04 | 2009-04-14 | 43 |  |  | 437d |  |  | Patrick Brandt | 240h |  |
| 52 | 11.3 | Prototype Enable Board | 2w | 2009-05-01 | 2009-05-14 | 44 |  |  | 415d |  |  | Mark Whitehead | 80h |  |
| 53 | 11.4 | Prototype Back Plane | 2w | 2009-04-10 | 2009-04-23 | 46 |  |  | 420d | 0d |  |  |  |  |
| 54 | 11.5 | LapTop Version | 2w | 2009-04-24 | 2009-05-07 | 53 |  |  | 420d |  |  |  |  |  |
| 55 | 11.6 | System Tests w Dewar | 3w | 2009-09-15 | 2009-10-05 | 115 |  |  | 313d |  |  |  |  |  |
| 56 | 12 | Data Analysis Pipeline | 24mo | 2008-02-12 | 2010-02-18 |  |  |  | 215d |  | start no earlier than 2008-02-12 | Bob Garwood | 4224h |  |
| 57 | 13 | Pipeline CDR | 2d | 2009-11-02 | 2009-11-03 |  |  |  | 292d |  | start no earlier than 2009-11-02 | Bob Garwood | 16h |  |

| ID | WBS | Task | Duration | Start | Finish | Predecessors | Complete | Remaining | Total slack | Free slack | Constraint | Resources | Work | Actual work |
| --- | --- | --- | --- | --- | --- | --- | --- | --- | --- | --- | --- | --- | --- | --- |
| 58 | 14 | **Pixel 2-7 Construction** | 689d | 2007-06-04 A | 2010-01-21 |  | 37% | 434.57d | 0d |  |  | Bob Simon | 13048h | 3130h |
| 59 | 14.1 | Feed | 3mo | 2008-10-01 A | 2008-12-31 A |  | 100% |  |  |  | start no earlier than 2008-10-01 | Harry Sipe | 528h | 528h |
| 60 | 14.2 | **OMT** | 29d | 2009-04-28 A | 2009-06-05 |  | 93% | 2d | 27d |  |  |  | 232h | 216h |
| 61 | 14.2.1 | CNC Fabricaton | 4w | 2009-04-28 A | 2009-05-25 A |  | 100% |  |  |  | start no earlier than 2009-04-28 | Dwayne Barker | 160h | 160h |
| 62 | 14.2.2 | Gold Plating | 1w | 2009-05-26 A | 2009-06-01 A | 61 | 100% |  |  |  |  | Petencin | 40h | 40h |
| 63 | 14.2.3 | Assembly | 2d | 2009-06-02 A | 2009-06-03 A | 62 | 100% |  |  |  |  | Ken Ward | 16h | 16h |
| 64 | 14.2.4 | OMT Testing | 2d | 2009-06-04 | 2009-06-05 | 63 |  |  | 27d |  |  | Bob Simon | 16h |  |
| 65 | 14.3 | **WR42 Thermal Transition** | 15d | 2009-05-26 A | 2009-06-15 | 61 | 96% | 0.6d | 158d |  |  |  | 200h | 192h |
| 66 | 14.3.1 | 70K Stage Machine | 15d | 2009-05-26 A | 2009-06-15 A |  | 100% |  |  |  | start no earlier than 2009-02-02 | Dwayne Barker | 120h | 120h |
| 67 | 14.3.2 | 70K Gold Plate | 1d | 2009-05-26 A | 2009-05-26 A |  | 100% |  |  |  | start no earlier than 2009-02-16 | Dwayne Barker | 8h | 8h |
| 68 | 14.3.3 | 300K Stage Machine | 5d | 2009-05-26 A | 2009-06-01 A |  | 100% |  |  |  | start no earlier than 2009-02-02 | Dwayne Barker | 40h | 40h |
| 69 | 14.3.4 | 300K Gold Plate | 1d | 2009-05-26 | 2009-05-26 |  |  |  | 172d |  | start no earlier than 2009-02-09 | Dwayne Barker | 8h |  |
| 70 | 14.3.5 | G10 Supports | 3d | 2009-05-27 A | 2009-05-29 A | 67 | 100% |  |  |  |  | Dwayne Barker | 24h | 24h |
| 71 | 14.4 | **Polarizer** | 243.4d | 2008-10-01 A | 2009-09-07 A |  | 100% |  |  |  |  |  | 1384h | 1384h |
| 72 | 14.4.1 | Mandrel Fabrication | 4mo | 2008-10-01 A | 2009-05-11 A |  | 100% |  |  |  | start no earlier than 2007-10-01 | Roger Dickenson | 704h | 704h |
| 73 | 14.4.2 | Electroforming | 13w | 2009-05-11 A | 2009-08-10 A | 72 | 100% |  |  |  |  | Gerry Petencin | 520h | 520h |
| 74 | 14.4.3 | Gold Plating and Finish | 2w | 2009-08-10 A | 2009-08-24 A | 73 | 100% |  |  |  |  | Roger Dickenson | 80h | 80h |
| 75 | 14.4.4 | Polarizer Testing | 2w | 2009-08-24 A | 2009-09-07 A | 74 | 100% |  |  |  |  | Sri | 80h | 80h |
| 76 | 14.5 | **Circular Thermal Transistion** | 523d | 2007-06-04 A | 2009-06-03 |  | 89% | 56.04d | 166d |  |  |  | 200h | 200h |
| 77 | 14.5.1 | Aluminum Machine | 20d | 2009-05-04 A | 2009-05-29 A |  | 100% |  |  |  | start no earlier than 2009-05-04 | Roger Dickenson | 160h | 160h |
| 78 | 14.5.2 | G10 Supports | 5d | 2007-06-04 A | 2007-06-08 A |  | 100% |  |  |  |  | Roger Dickenson | 40h | 40h |
| 79 | 14.5.3 | Gold Plating | 3d | 2009-06-01 | 2009-06-03 | 77 |  |  | 166d |  |  |  |  |  |
| 80 | 14.6 | Waveguide Construction | 10d | 2008-02-04 A | 2008-02-15 A |  | 100% |  |  |  | start no earlier than 2008-02-04 | Roger Dickenson | 80h | 80h |
| 81 | 14.7 | **15 K Cold Plate** | 60d | 2009-03-02 A | 2009-05-22 |  | 73% | 16.36d | 37d |  |  |  | 440h | 320h |
| 82 | 14.7.1 | Design | 8w | 2009-03-02 A | 2009-04-24 A |  | 100% |  |  |  | start no earlier than 2009-03-02 | Bob Simon | 320h | 320h |
| 83 | 14.7.2 | Machining | 1w | 2009-05-04 | 2009-05-08 | 82 |  |  | 37d | 0d | start no earlier than 2009-05-04 | Roger Dickenson | 40h |  |
| 84 | 14.7.3 | Gold Plating | 2w | 2009-05-11 | 2009-05-22 | 83 |  |  | 37d |  |  | Petincin | 80h |  |

| ID | WBS | Task | Duration | Start | Finish | Predecessors | Complete | Remaining | Total slack | Free slack | Constraint | Resources | Work | Actual work |
| --- | --- | --- | --- | --- | --- | --- | --- | --- | --- | --- | --- | --- | --- | --- |
| 85 | 14.8 | **Radiation Shields** | 60d | 2009-04-20 A | 2009-07-10 |  | 33% | 40.05d | 2d |  |  |  | 80h | 53.2h |
| 86 | 14.8.1 | Design | 5d | 2009-04-20 A | 2009-04-24 A |  | 100% |  |  |  | start no earlier than 2009-04-20 | Bob Simon | 40h | 40h |
| 87 | 14.8.2 | Machining | 5d | 2009-06-22 A | 2009-06-26 | 86 | 33% | 3.35d | 2d | 0d | start no earlier than 2009-04-27 | Roger Dickenson | 40h | 13.2h |
| 88 | 14.8.3 | Vendor Nickel Plating | 10d | 2009-06-29 | 2009-07-10 | 87 |  |  | 2d |  |  |  |  |  |
| 89 | 14.9 | Complete IDM | 6mo | 2009-02-02 | 2009-08-04 |  |  |  | 122d |  | start no earlier than 2009-02-02 | Matt Morgan | 1056h |  |
| 90 | 14.10 | Complete NCM | 5mo | 2009-02-02 | 2009-07-03 |  |  |  | 7d |  | start no earlier than 2009-02-02 | Eric Bryerton | 880h |  |
| 91 | 14.11 | **Complete LO Distribution** | 75d | 2009-03-02 A | 2009-06-12 |  | 5% | 71.21d | 159d |  |  |  | 1200h | 104h |
| 92 | 14.11.1 | Pretests | 6d | 2009-03-02 A | 2009-03-09 A |  | 100% |  |  |  | start no earlier than 2009-03-02 | Gary Anderson | 48h | 48h |
| 93 | 14.11.2 | Produce additional fixtures | 5d | 2009-03-10 | 2009-03-16 | 92 |  |  | 194d | 8d |  |  |  |  |
| 94 | 14.11.3 | Test old filter, Mult | 36d | 2009-03-27 A | 2009-05-15 | 93 | 19% | 29d | 179d |  |  | Gary Anderson | 288h | 56h |
| 95 | 14.11.4 | Design Equalizer | 5d | 2009-05-04 | 2009-05-08 |  |  |  | 184d |  | start no earlier than 2009-05-04 |  |  |  |
| 96 | 14.11.5 | Fab new filter | 36d | 2009-03-27 | 2009-05-15 |  |  |  | 179d |  | start no earlier than 2009-03-27 | Gary Anderson | 288h |  |
| 97 | 14.11.6 | Fab splitters | 36d | 2009-03-27 | 2009-05-15 |  |  |  | 179d |  | start no earlier than 2009-03-27 | Gary Anderson | 288h |  |
| 98 | 14.11.7 | Order bypass caps | 36d | 2009-03-20 | 2009-05-08 |  |  |  | 184d |  | start no earlier than 2009-03-20 | Gary Anderson | 288h |  |
| 99 | 14.11.8 | Order Amplifiers | 41d | 2009-03-20 | 2009-05-15 |  |  |  | 179d |  | start no earlier than 2009-03-20 |  |  |  |
| 100 | 14.11.9 | Finish design chassis, carriers | 23d | 2009-03-23 | 2009-04-22 |  |  |  | 163d | 2d | start no earlier than 2009-03-23 |  |  |  |
| 101 | 14.11.10 | Fab Chassis, carriers | 20d | 2009-04-27 | 2009-05-22 | 100 |  |  | 161d | 0d | start no earlier than 2009-04-27 |  |  |  |
| 102 | 14.11.11 | Assemble | 10d | 2009-05-25 | 2009-06-05 | 101 |  |  | 161d | 2d |  |  |  |  |
| 103 | 14.11.12 | **Test** | 3d | 2009-06-10 | 2009-06-12 | 102 |  |  | 159d |  |  |  |  |  |
| 104 | 14.11.12.1 | Pout vsFrequency | 1d | 2009-06-10 | 2009-06-10 |  |  |  | 159d | 0d | start no earlier than 2009-06-10 |  |  |  |
| 105 | 14.11.12.2 | Temp Stability | 1d | 2009-06-11 | 2009-06-11 | 104 |  |  | 159d | 0d | start no earlier than 2009-06-10 |  |  |  |
| 106 | 14.11.12.3 | Isolation | 1d | 2009-06-12 | 2009-06-12 | 105 |  |  | 159d |  | start no earlier than 2009-06-10 |  |  |  |
| 108 | 14.12 | **Dewar Parts Fabrication** | 57d | 2009-04-27 A | 2009-07-14 |  | 43% | 32.73d | 0d |  |  |  | 160h | 52.8h |
| 109 | 14.12.1 | Radome Assembly | 5d | 2009-06-15 A | 2009-06-19 A |  | 100% |  |  |  | start no earlier than 2009-06-15 |  |  |  |
| 110 | 14.12.2 | FabricateTop Plate | 10d | 2009-04-27 A | 2009-05-08 |  | 66% | 3.4d | 30.3d | 25d | start no earlier than 2009-04-27 | Harry Sipe | 80h | 52.8h |
| 111 | 14.12.3 | Fabricate Center Plate | 10d | 2009-06-15 A | 2009-06-26 | 110 | 33% | 6.7d | 2d |  |  |  |  |  |
| 112 | 14.12.4 | Fabricate Cylinder | 5d | 2009-07-01 | 2009-07-07 | 111 |  |  | 0d |  | start no earlier than 2009-07-01 | Harry Sipe | 40h |  |
| 113 | 14.12.5 | Fabricate Bottom Plate | 5d | 2009-07-08 | 2009-07-14 | 112 |  |  | 0d |  |  | Harry Sipe | 40h |  |
| 114 | 14.13 | Receiver Frame | 5d | 2009-07-01 | 2009-07-07 |  |  |  | 142d |  | start no earlier than 2009-07-01 |  |  |  |
| 115 | 14.14 | Dewar Assembly | 2mo | 2009-07-15 | 2009-09-14 | 81, 85, 90, 70, 43, 108, 60 |  |  | 0d |  |  | Ken Ward | 352h |  |
| 116 | 14.15 | Integrate Dewar & Frame | 4mo | 2009-09-15 | 2010-01-14 | 115 |  |  | 0d |  |  | Ken Ward | 704h |  |
| 117 | 14.16 | Integrate Cable Wrap | 1w | 2010-01-15 | 2010-01-21 | 116 |  |  | 0d |  |  | Ken Ward | 40h |  |
| 118 | 15 | System Integrate & LAB Test | 3w | 2010-01-22 | 2010-02-11 | 58 |  |  | 0d |  |  | Bob Simon | 120h |  |
| 119 | 16 | Telescope Testing | 1mo | 2010-02-12 | 2010-03-15 | 118 |  |  | 0d |  |  | Glen Langston | 176h |  |
| 120 | 17 | Install & Commission | 9mo | 2010-03-16 | 2010-12-16 | 119 |  |  | 0d |  |  |  |  |  |
